# Constraints and Deadlines

How a schedule from MS Project changed from version to version. A marks actual dates.

## Version 1 (saved 2019-03-06, file Constraints and Deadlines.mpp)

| ID | WBS | Task | Duration | Start | Finish | Predecessors | Total float |
| --- | --- | --- | --- | --- | --- | --- | --- |
| 1 | 1 | **General Conditions** | 16d | 2019-03-01 | 2019-03-22 |  | 0.12d |
| 2 |  | Complete plans and develop estimate with owner, architect | 3w | 2019-03-01 | 2019-03-21 |  | 0.12d |
| 3 |  | Sign contract and notice to proceed | 1d | 2019-03-22 | 2019-03-22 | 2 | 0.12d |
| 4 | 1.3 | **Apply for Permits** | 0d | 2019-03-22 | 2019-03-22 |  | 0.12d |
| 5 |  | Secure foundaton permit | 0d | 2019-03-22 | 2019-03-22 | 3 | 0.12d |
| 6 |  | Secure framing permit | 0d | 2019-03-22 | 2019-03-22 | 3 | 0.12d |
| 7 |  | Secure electrical permit | 0d | 2019-03-22 | 2019-03-22 | 3 | 0.12d |
| 8 |  | Secure plumbing permit | 0d | 2019-03-22 | 2019-03-22 | 3 | 0.12d |
| 9 |  | Secure HVAC permit | 0d | 2019-03-22 | 2019-03-22 | 3 | 0.12d |
| 10 |  | Secure miscellaneous permits | 0d | 2019-03-22 | 2019-03-22 | 3 | 0.12d |
| 11 | 2 | **Site Work** | 2.75d | 2019-03-25 | 2019-03-27 |  | 0.12d |
| 12 |  | Clear site | 1d | 2019-03-25 | 2019-03-25 | 5, 6, 7, 8, 9, 10 | 0.12d |
| 13 |  | Install temporary power service | 6h | 2019-03-26 | 2019-03-26 | 12 | 0.12d |
| 14 |  | Install underground utilities | 1d | 2019-03-26 | 2019-03-27 | 13 | 0.12d |
| 15 | 3 | **Foundation** | 13.25d | 2019-03-27 | 2019-04-15 |  | 0d |
| 16 |  | Excavate for foundations | 3d | 2019-03-27 | 2019-04-01 | 14 | 0.12d |
| 17 |  | Form basement walls | 13d | 2019-04-01 | 2019-04-05 | 16 | 0d |
| 18 |  | Pour concrete for foundations & basement walls | 12d | 2019-04-05 | 2019-04-09 | 17 | 0d |
| 19 |  | Strip basement wall forms | 2d | 2019-04-09 | 2019-04-10 | 18 | 0d |
| 20 |  | Waterproof/insulate basement walls | 2d | 2019-04-10 | 2019-04-11 | 19 | 0d |
| 21 |  | Perform foundation inspection | 1d | 2019-04-11 | 2019-04-11 | 20, 16 | 0d |
| 22 |  | Backfill foundation | 2d | 2019-04-12 | 2019-04-15 | 21 | 0d |
| 23 | 4 | **Framing** | 21.75d | 2019-04-16 | 2019-05-15 |  | 0d |
| 24 |  | Install 1st floor joists | 2d | 2019-04-16 | 2019-04-17 | 22 | 0d |
| 25 |  | Lay 1st floor decking | 2d | 2019-04-18 | 2019-04-19 | 24 | 0d |
| 26 |  | Frame 1st floor walls | 4d | 2019-04-22 | 2019-04-25 | 25 | 0d |
| 27 |  | Frame 1st floor corners | 1d | 2019-04-26 | 2019-04-26 | 26 | 0d |
| 28 |  | Install 2nd floor joists | 2d | 2019-04-29 | 2019-04-30 | 27 | 0d |
| 29 |  | Frame 2nd floor decking | 2d | 2019-05-01 | 2019-05-02 | 28 | 0d |
| 30 |  | Frame 2nd floor walls | 3d | 2019-05-03 | 2019-05-07 | 29 | 0d |
| 31 |  | Frame 2nd floor corners | 2d | 2019-05-08 | 2019-05-09 | 30 | 0d |
| 32 |  | Complete roof framing | 3d | 2019-05-10 | 2019-05-14 | 31 | 0d |
| 33 |  | Conduct framing inspection | 6h | 2019-05-15 | 2019-05-15 | 32 | 0d |
| 34 | 5 | **Dry In** | 21.75d | 2019-05-15 | 2019-06-13 |  | 0d |
| 35 |  | Install 1st floor sheathing | 3d | 2019-05-15 | 2019-05-20 | 33 | 0d |
| 36 |  | Install 2nd floor sheathing | 3d | 2019-05-20 | 2019-05-23 | 35 | 0d |
| 37 |  | Install roof decking | 3d | 2019-05-15 | 2019-05-17 | 32 | 3.75d |
| 38 |  | Install felt, flashing and shingles | 3d | 2019-05-30 | 2019-06-04 | 46 | 0d |
| 39 |  | Hang 1st floor exterior doors | 1d | 2019-06-04 | 2019-06-05 | 38 | 0d |
| 40 |  | Install 1st floor windows | 3d | 2019-06-05 | 2019-06-10 | 39 | 0d |
| 41 |  | Install 2nd floor windows | 3d | 2019-06-10 | 2019-06-13 | 40 | 0d |
| 42 | 6 | **Exterior Finishes** | 13d | 2019-06-13 | 2019-07-02 |  | 12.25d |
| 43 |  | Complete exterior brick | 2w | 2019-06-13 | 2019-06-27 | 41 | 12.25d |
| 44 |  | Complete exterior siding | 3d | 2019-06-27 | 2019-07-02 | 43 | 12.25d |
| 45 | 7 | **Utility Rough-Ins and Complete Concrete** | 13.75d | 2019-05-20 | 2019-06-06 |  | 3.75d |
| 46 |  | Rough-in plumbing | 5d | 2019-05-23 | 2019-05-30 | 37, 36 | 0d |
| 47 |  | Conduct rough-in plumbing inspection | 1d | 2019-05-30 | 2019-05-31 | 46 | 20d |
| 48 |  | Place concrete for basement floor | 2w | 2019-05-31 | 2019-06-03 | 47 | 40.25d |
| 49 |  | Rough-in electrical | 5d | 2019-05-23 | 2019-05-30 | 37, 36 | 6d |
| 50 |  | Conduct rough-in electrical inspection | 1d | 2019-05-30 | 2019-05-31 | 49 | 6d |
| 51 |  | Rough-in HVAC | 3d | 2019-05-31 | 2019-06-05 | 50 | 6d |
| 52 |  | Conduct rough-in HVAC inspection | 1d | 2019-06-05 | 2019-06-06 | 51 | 24d |
| 53 |  | Rough-in communication - phone, cable, computer, alarm | 2d | 2019-05-20 | 2019-05-21 | 37 | 16.75d |
| 54 | 8 | **Interior Finishes** | 30d | 2019-06-13 | 2019-07-25 |  | 0d |
| 55 | 8.1 | **Insulation** | 11d | 2019-06-13 | 2019-06-28 |  | 0d |
| 56 |  | Place wall insulation - 1st floor | 1d | 2019-06-13 | 2019-06-14 | 35, 41, 53, 51, 49, 36 | 0d |
| 57 |  | Place wall insulation - 2nd floor | 1d | 2019-06-14 | 2019-06-17 | 56 | 27d |
| 58 |  | Place ceiling insulation - 2nd floor | 1d | 2019-06-26 | 2019-06-27 | 64, 57 | 24d |
| 59 |  | Conduct insulation inspection | 1d | 2019-06-27 | 2019-06-28 | 58 | 24d |
| 60 | 8.2 | **Drywall** | 9d | 2019-06-14 | 2019-06-27 |  | 0d |
| 61 |  | Install drywall - 1st floor walls | 2d | 2019-06-14 | 2019-06-18 | 56 | 0d |
| 62 |  | Install drywall - 1st floor overhead | 2d | 2019-06-18 | 2019-06-20 | 61 | 0d |
| 63 |  | Install drywall 2nd floor walls | 2d | 2019-06-20 | 2019-06-24 | 62, 57 | 24d |
| 64 |  | Install drywall 2nd floor overhead | 2d | 2019-06-24 | 2019-06-26 | 63 | 24d |
| 65 |  | Tape and float 1st floor drywall | 1d | 2019-06-20 | 2019-06-21 | 62 | 0d |
| 66 |  | Tape and float 2nd floor drywall | 1d | 2019-06-26 | 2019-06-27 | 64, 65 | 32.5d |
| 67 | 8.3 | **Paint and Wallpaper** | 11d | 2019-06-21 | 2019-07-08 |  | 0d |
| 68 |  | Texture all except entry and kitchen - 1st floor | 1d | 2019-06-21 | 2019-06-24 | 65 | 0d |
| 69 |  | Paint all except entry and kitchen - 1st floor | 1d | 2019-06-24 | 2019-06-25 | 68 | 0d |
| 70 |  | Hang wallpaper entry and kitchen - 1st floor | 1d | 2019-06-25 | 2019-06-26 | 69 | 0d |

| ID | WBS | Task | Duration | Start | Finish | Predecessors | Total float |
| --- | --- | --- | --- | --- | --- | --- | --- |
| 71 |  | Texture all - 2nd floor | 1d | 2019-06-24 | 2019-06-25 | 68 | 33.5d |
| 72 |  | Paint all - 2nd floor | 1d | 2019-06-25 | 2019-06-26 | 71 | 33.5d |
| 73 |  | Paint exterior siding & trim work | 4d | 2019-07-02 | 2019-07-08 | 44 | 12.25d |
| 74 | 8.4 | **Cabinets** | 6d | 2019-06-26 | 2019-07-04 |  | 0d |
| 75 |  | Install 1st floor - kitchen cabinets | 2d | 2019-06-26 | 2019-06-28 | 70 | 0d |
| 76 |  | Install 1st floor - master bath and guest cabinets | 1d | 2019-06-28 | 2019-07-01 | 75 | 0d |
| 77 |  | Install 2nd floor - hall bath and private bath cabinets | 1d | 2019-07-01 | 2019-07-02 | 76 | 1d |
| 78 |  | Install chair rails, crown moldings, trim | 2d | 2019-07-02 | 2019-07-04 | 77 | 20d |
| 79 | 8.5 | **Finish Plumbing** | 6d | 2019-06-28 | 2019-07-08 |  | 0d |
| 80 |  | Complete 1st floor - kitchen plumbing | 1d | 2019-06-28 | 2019-07-01 | 75, 47 | 0d |
| 81 |  | Complete 1st floor - master bath and guest plumbing | 2d | 2019-07-01 | 2019-07-03 | 80, 76 | 0d |
| 82 |  | Complete 2nd floor - hall bath and private bath plumbing | 2d | 2019-07-03 | 2019-07-05 | 81, 77 | 0d |
| 83 |  | Conduct finish plumbing inspection | 1d | 2019-07-05 | 2019-07-08 | 82 | 0d |
| 84 | 8.6 | **Finish Electrical** | 3d | 2019-07-05 | 2019-07-10 |  | 1d |
| 85 |  | Complete 1st floor circuits to service panel | 1d | 2019-07-05 | 2019-07-08 | 82, 50 | 3d |
| 86 |  | Complete 2nd floor circuits to service panel | 1d | 2019-07-08 | 2019-07-09 | 85 | 3d |
| 87 |  | Conduct finish electrical inspection | 1d | 2019-07-09 | 2019-07-10 | 86 | 3d |
| 88 |  | Complete communications wiring - phone, cable, computer, alarm | 2d | 2019-07-08 | 2019-07-10 | 83 | 0d |
| 89 | 8.7 | **Finish HVAC** | 3d | 2019-07-10 | 2019-07-15 |  | 0d |
| 90 |  | Complete 1st floor - zone 1 HVAC | 1d | 2019-07-10 | 2019-07-11 | 88, 52 | 0d |
| 91 |  | Complete 2nd floor - zone 2 HVAC | 1d | 2019-07-11 | 2019-07-12 | 90 | 0d |
| 92 |  | Conduct HVAC inspection | 1d | 2019-07-12 | 2019-07-15 | 91 | 0d |
| 93 | 8.8 | **Carpet, Tile and Appliances** | 8d | 2019-07-15 | 2019-07-25 |  | 0d |
| 94 |  | Tile entry, kitchen and baths | 3d | 2019-07-15 | 2019-07-18 | 87, 92 | 0d |
| 95 |  | Carpet 1st floor | 2d | 2019-07-18 | 2019-07-22 | 94 | 0d |
| 96 |  | Carpet 2nd floor | 2d | 2019-07-22 | 2019-07-24 | 95 | 0d |
| 97 |  | Install appliances | 1d | 2019-07-24 | 2019-07-25 | 96 | 0d |
| 98 | 9 | **Landscaping and Grounds Work** | 18d | 2019-07-08 | 2019-08-01 |  | 0d |
| 99 |  | Pour concrete driveway and sidewalks | 2d | 2019-07-08 | 2019-07-09 | 73 | 12.25d |
| 100 |  | Install backyard fence | 2d | 2019-07-25 | 2019-07-29 | 97, 99 | 0d |
| 101 |  | Sod and complete plantings - front yard | 2d | 2019-07-29 | 2019-07-31 | 100 | 0d |
| 102 |  | Sod and complete plantings - backyard | 1d | 2019-07-31 | 2019-08-01 | 101 | 0d |
| 103 | 10 | **Final Acceptance** | 7.5d | 2019-08-01 | 2019-08-13 |  | 0d |
| 104 |  | Complete final inspection for certificate of occupancy | 6h | 2019-08-01 | 2019-08-02 | 102, 92, 87, 83, 59, 78, 48 | 0d |
| 105 |  | Cleanup for occupancy | 1d | 2019-08-02 | 2019-08-05 | 97, 104 | 0d |
| 106 |  | Perform final walk-through inspection | 1d | 2019-08-05 | 2019-08-06 | 105 | 0d |
| 107 |  | Complete punch list items | 5d | 2019-08-06 | 2019-08-13 | 106FS-2.5% | 0d |

## Version 2 (saved 2019-03-06, file Work Contouring.mpp)

Last finish 2019-08-13 → 2019-08-27 (+14d).

Changed:

| ID | Task | Start | Finish | Duration |
| --- | --- | --- | --- | --- |
| 1 | **General Conditions** |  | 2019-03-22 → 2019-04-05 (+14d) | 16d → 26d |
| 2 | Complete plans and develop estimate with owner, architect |  | 2019-03-21 → 2019-04-04 (+14d) | 3w → 5w |
| 3 | Sign contract and notice to proceed | 2019-03-22 → 2019-04-05 (+14d) | 2019-03-22 → 2019-04-05 (+14d) |  |
| 4 | **Apply for Permits** | 2019-03-22 → 2019-04-05 (+14d) | 2019-03-22 → 2019-04-05 (+14d) |  |
| 5 | Secure foundaton permit | 2019-03-22 → 2019-04-05 (+14d) | 2019-03-22 → 2019-04-05 (+14d) |  |
| 6 | Secure framing permit | 2019-03-22 → 2019-04-05 (+14d) | 2019-03-22 → 2019-04-05 (+14d) |  |
| 7 | Secure electrical permit | 2019-03-22 → 2019-04-05 (+14d) | 2019-03-22 → 2019-04-05 (+14d) |  |
| 8 | Secure plumbing permit | 2019-03-22 → 2019-04-05 (+14d) | 2019-03-22 → 2019-04-05 (+14d) |  |
| 9 | Secure HVAC permit | 2019-03-22 → 2019-04-05 (+14d) | 2019-03-22 → 2019-04-05 (+14d) |  |
| 10 | Secure miscellaneous permits | 2019-03-22 → 2019-04-05 (+14d) | 2019-03-22 → 2019-04-05 (+14d) |  |
| 11 | **Site Work** | 2019-03-25 → 2019-04-08 (+14d) | 2019-03-27 → 2019-04-10 (+14d) |  |
| 12 | Clear site | 2019-03-25 → 2019-04-08 (+14d) | 2019-03-25 → 2019-04-08 (+14d) |  |
| 13 | Install temporary power service | 2019-03-26 → 2019-04-09 (+14d) | 2019-03-26 → 2019-04-09 (+14d) |  |
| 14 | Install underground utilities | 2019-03-26 → 2019-04-09 (+14d) | 2019-03-27 → 2019-04-10 (+14d) |  |
| 15 | **Foundation** | 2019-03-27 → 2019-04-10 (+14d) | 2019-04-15 → 2019-04-29 (+14d) |  |
| 16 | Excavate for foundations | 2019-03-27 → 2019-04-10 (+14d) | 2019-04-01 → 2019-04-15 (+14d) |  |
| 17 | Form basement walls | 2019-04-01 → 2019-04-15 (+14d) | 2019-04-05 → 2019-04-19 (+14d) |  |
| 18 | Pour concrete for foundations & basement walls | 2019-04-05 → 2019-04-19 (+14d) | 2019-04-09 → 2019-04-23 (+14d) |  |
| 19 | Strip basement wall forms | 2019-04-09 → 2019-04-23 (+14d) | 2019-04-10 → 2019-04-24 (+14d) |  |
| 20 | Waterproof/insulate basement walls | 2019-04-10 → 2019-04-24 (+14d) | 2019-04-11 → 2019-04-25 (+14d) |  |
| 21 | Perform foundation inspection | 2019-04-11 → 2019-04-25 (+14d) | 2019-04-11 → 2019-04-25 (+14d) |  |
| 22 | Backfill foundation | 2019-04-12 → 2019-04-26 (+14d) | 2019-04-15 → 2019-04-29 (+14d) |  |
| 23 | **Framing** | 2019-04-16 → 2019-04-30 (+14d) | 2019-05-15 → 2019-05-29 (+14d) |  |
| 24 | Install 1st floor joists | 2019-04-16 → 2019-04-30 (+14d) | 2019-04-17 → 2019-05-01 (+14d) |  |
| 25 | Lay 1st floor decking | 2019-04-18 → 2019-05-02 (+14d) | 2019-04-19 → 2019-05-03 (+14d) |  |
| 26 | Frame 1st floor walls | 2019-04-22 → 2019-05-06 (+14d) | 2019-04-25 → 2019-05-09 (+14d) |  |
| 27 | Frame 1st floor corners | 2019-04-26 → 2019-05-10 (+14d) | 2019-04-26 → 2019-05-10 (+14d) |  |
| 28 | Install 2nd floor joists | 2019-04-29 → 2019-05-13 (+14d) | 2019-04-30 → 2019-05-14 (+14d) |  |
| 29 | Frame 2nd floor decking | 2019-05-01 → 2019-05-15 (+14d) | 2019-05-02 → 2019-05-16 (+14d) |  |
| 30 | Frame 2nd floor walls | 2019-05-03 → 2019-05-17 (+14d) | 2019-05-07 → 2019-05-21 (+14d) |  |
| 31 | Frame 2nd floor corners | 2019-05-08 → 2019-05-22 (+14d) | 2019-05-09 → 2019-05-23 (+14d) |  |
| 32 | Complete roof framing | 2019-05-10 → 2019-05-24 (+14d) | 2019-05-14 → 2019-05-28 (+14d) |  |
| 33 | Conduct framing inspection | 2019-05-15 → 2019-05-29 (+14d) | 2019-05-15 → 2019-05-29 (+14d) |  |
| 34 | **Dry In** | 2019-05-15 → 2019-05-29 (+14d) | 2019-06-13 → 2019-06-27 (+14d) |  |
| 35 | Install 1st floor sheathing | 2019-05-15 → 2019-05-29 (+14d) | 2019-05-20 → 2019-06-03 (+14d) |  |
| 36 | Install 2nd floor sheathing | 2019-05-20 → 2019-06-03 (+14d) | 2019-05-23 → 2019-06-06 (+14d) |  |
| 37 | Install roof decking | 2019-05-15 → 2019-05-29 (+14d) | 2019-05-17 → 2019-05-31 (+14d) |  |
| 38 | Install felt, flashing and shingles | 2019-05-30 → 2019-06-13 (+14d) | 2019-06-04 → 2019-06-18 (+14d) |  |
| 39 | Hang 1st floor exterior doors | 2019-06-04 → 2019-06-18 (+14d) | 2019-06-05 → 2019-06-19 (+14d) |  |
| 40 | Install 1st floor windows | 2019-06-05 → 2019-06-19 (+14d) | 2019-06-10 → 2019-06-24 (+14d) |  |
| 41 | Install 2nd floor windows | 2019-06-10 → 2019-06-24 (+14d) | 2019-06-13 → 2019-06-27 (+14d) |  |
| 42 | **Exterior Finishes** | 2019-06-13 → 2019-06-27 (+14d) | 2019-07-02 → 2019-07-16 (+14d) |  |
| 43 | Complete exterior brick | 2019-06-13 → 2019-06-27 (+14d) | 2019-06-27 → 2019-07-11 (+14d) |  |
| 44 | Complete exterior siding | 2019-06-27 → 2019-07-11 (+14d) | 2019-07-02 → 2019-07-16 (+14d) |  |
| 45 | **Utility Rough-Ins and Complete Concrete** | 2019-05-20 → 2019-06-03 (+14d) | 2019-06-06 → 2019-06-20 (+14d) |  |
| 46 | Rough-in plumbing | 2019-05-23 → 2019-06-06 (+14d) | 2019-05-30 → 2019-06-13 (+14d) |  |
| 47 | Conduct rough-in plumbing inspection | 2019-05-30 → 2019-06-13 (+14d) | 2019-05-31 → 2019-06-14 (+14d) |  |
| 48 | Place concrete for basement floor | 2019-05-31 → 2019-06-14 (+14d) | 2019-06-03 → 2019-06-17 (+14d) |  |
| 49 | Rough-in electrical | 2019-05-23 → 2019-06-06 (+14d) | 2019-05-30 → 2019-06-13 (+14d) |  |
| 50 | Conduct rough-in electrical inspection | 2019-05-30 → 2019-06-13 (+14d) | 2019-05-31 → 2019-06-14 (+14d) |  |
| 51 | Rough-in HVAC | 2019-05-31 → 2019-06-14 (+14d) | 2019-06-05 → 2019-06-19 (+14d) |  |
| 52 | Conduct rough-in HVAC inspection | 2019-06-05 → 2019-06-19 (+14d) | 2019-06-06 → 2019-06-20 (+14d) |  |
| 53 | Rough-in communication - phone, cable, computer, alarm | 2019-05-20 → 2019-06-03 (+14d) | 2019-05-21 → 2019-06-04 (+14d) |  |
| 54 | **Interior Finishes** | 2019-06-13 → 2019-06-27 (+14d) | 2019-07-25 → 2019-08-08 (+14d) |  |
| 55 | **Insulation** | 2019-06-13 → 2019-06-27 (+14d) | 2019-06-28 → 2019-07-12 (+14d) |  |
| 56 | Place wall insulation - 1st floor | 2019-06-13 → 2019-06-27 (+14d) | 2019-06-14 → 2019-06-28 (+14d) |  |
| 57 | Place wall insulation - 2nd floor | 2019-06-14 → 2019-06-28 (+14d) | 2019-06-17 → 2019-07-01 (+14d) |  |
| 58 | Place ceiling insulation - 2nd floor | 2019-06-26 → 2019-07-10 (+14d) | 2019-06-27 → 2019-07-11 (+14d) |  |
| 59 | Conduct insulation inspection | 2019-06-27 → 2019-07-11 (+14d) | 2019-06-28 → 2019-07-12 (+14d) |  |
| 60 | **Drywall** | 2019-06-14 → 2019-06-28 (+14d) | 2019-06-27 → 2019-07-11 (+14d) |  |
| 61 | Install drywall - 1st floor walls | 2019-06-14 → 2019-06-28 (+14d) | 2019-06-18 → 2019-07-02 (+14d) |  |
| 62 | Install drywall - 1st floor overhead | 2019-06-18 → 2019-07-02 (+14d) | 2019-06-20 → 2019-07-04 (+14d) |  |
| 63 | Install drywall 2nd floor walls | 2019-06-20 → 2019-07-04 (+14d) | 2019-06-24 → 2019-07-08 (+14d) |  |
| 64 | Install drywall 2nd floor overhead | 2019-06-24 → 2019-07-08 (+14d) | 2019-06-26 → 2019-07-10 (+14d) |  |
| 65 | Tape and float 1st floor drywall | 2019-06-20 → 2019-07-04 (+14d) | 2019-06-21 → 2019-07-05 (+14d) |  |
| 66 | Tape and float 2nd floor drywall | 2019-06-26 → 2019-07-10 (+14d) | 2019-06-27 → 2019-07-11 (+14d) |  |
| 67 | **Paint and Wallpaper** | 2019-06-21 → 2019-07-05 (+14d) | 2019-07-08 → 2019-07-22 (+14d) |  |
| 68 | Texture all except entry and kitchen - 1st floor | 2019-06-21 → 2019-07-05 (+14d) | 2019-06-24 → 2019-07-08 (+14d) |  |
| 69 | Paint all except entry and kitchen - 1st floor | 2019-06-24 → 2019-07-08 (+14d) | 2019-06-25 → 2019-07-09 (+14d) |  |
| 70 | Hang wallpaper entry and kitchen - 1st floor | 2019-06-25 → 2019-07-09 (+14d) | 2019-06-26 → 2019-07-10 (+14d) |  |

| ID | Task | Start | Finish |
| --- | --- | --- | --- |
| 71 | Texture all - 2nd floor | 2019-06-24 → 2019-07-08 (+14d) | 2019-06-25 → 2019-07-09 (+14d) |
| 72 | Paint all - 2nd floor | 2019-06-25 → 2019-07-09 (+14d) | 2019-06-26 → 2019-07-10 (+14d) |
| 73 | Paint exterior siding & trim work | 2019-07-02 → 2019-07-16 (+14d) | 2019-07-08 → 2019-07-22 (+14d) |
| 74 | **Cabinets** | 2019-06-26 → 2019-07-10 (+14d) | 2019-07-04 → 2019-07-18 (+14d) |
| 75 | Install 1st floor - kitchen cabinets | 2019-06-26 → 2019-07-10 (+14d) | 2019-06-28 → 2019-07-12 (+14d) |
| 76 | Install 1st floor - master bath and guest cabinets | 2019-06-28 → 2019-07-12 (+14d) | 2019-07-01 → 2019-07-15 (+14d) |
| 77 | Install 2nd floor - hall bath and private bath cabinets | 2019-07-01 → 2019-07-15 (+14d) | 2019-07-02 → 2019-07-16 (+14d) |
| 78 | Install chair rails, crown moldings, trim | 2019-07-02 → 2019-07-16 (+14d) | 2019-07-04 → 2019-07-18 (+14d) |
| 79 | **Finish Plumbing** | 2019-06-28 → 2019-07-12 (+14d) | 2019-07-08 → 2019-07-22 (+14d) |
| 80 | Complete 1st floor - kitchen plumbing | 2019-06-28 → 2019-07-12 (+14d) | 2019-07-01 → 2019-07-15 (+14d) |
| 81 | Complete 1st floor - master bath and guest plumbing | 2019-07-01 → 2019-07-15 (+14d) | 2019-07-03 → 2019-07-17 (+14d) |
| 82 | Complete 2nd floor - hall bath and private bath plumbing | 2019-07-03 → 2019-07-17 (+14d) | 2019-07-05 → 2019-07-19 (+14d) |
| 83 | Conduct finish plumbing inspection | 2019-07-05 → 2019-07-19 (+14d) | 2019-07-08 → 2019-07-22 (+14d) |
| 84 | **Finish Electrical** | 2019-07-05 → 2019-07-19 (+14d) | 2019-07-10 → 2019-07-24 (+14d) |
| 85 | Complete 1st floor circuits to service panel | 2019-07-05 → 2019-07-19 (+14d) | 2019-07-08 → 2019-07-22 (+14d) |
| 86 | Complete 2nd floor circuits to service panel | 2019-07-08 → 2019-07-22 (+14d) | 2019-07-09 → 2019-07-23 (+14d) |
| 87 | Conduct finish electrical inspection | 2019-07-09 → 2019-07-23 (+14d) | 2019-07-10 → 2019-07-24 (+14d) |
| 88 | Complete communications wiring - phone, cable, computer, alarm | 2019-07-08 → 2019-07-22 (+14d) | 2019-07-10 → 2019-07-24 (+14d) |
| 89 | **Finish HVAC** | 2019-07-10 → 2019-07-24 (+14d) | 2019-07-15 → 2019-07-29 (+14d) |
| 90 | Complete 1st floor - zone 1 HVAC | 2019-07-10 → 2019-07-24 (+14d) | 2019-07-11 → 2019-07-25 (+14d) |
| 91 | Complete 2nd floor - zone 2 HVAC | 2019-07-11 → 2019-07-25 (+14d) | 2019-07-12 → 2019-07-26 (+14d) |
| 92 | Conduct HVAC inspection | 2019-07-12 → 2019-07-26 (+14d) | 2019-07-15 → 2019-07-29 (+14d) |
| 93 | **Carpet, Tile and Appliances** | 2019-07-15 → 2019-07-29 (+14d) | 2019-07-25 → 2019-08-08 (+14d) |
| 94 | Tile entry, kitchen and baths | 2019-07-15 → 2019-07-29 (+14d) | 2019-07-18 → 2019-08-01 (+14d) |
| 95 | Carpet 1st floor | 2019-07-18 → 2019-08-01 (+14d) | 2019-07-22 → 2019-08-05 (+14d) |
| 96 | Carpet 2nd floor | 2019-07-22 → 2019-08-05 (+14d) | 2019-07-24 → 2019-08-07 (+14d) |
| 97 | Install appliances | 2019-07-24 → 2019-08-07 (+14d) | 2019-07-25 → 2019-08-08 (+14d) |
| 98 | **Landscaping and Grounds Work** | 2019-07-08 → 2019-07-22 (+14d) | 2019-08-01 → 2019-08-15 (+14d) |
| 99 | Pour concrete driveway and sidewalks | 2019-07-08 → 2019-07-22 (+14d) | 2019-07-09 → 2019-07-23 (+14d) |
| 100 | Install backyard fence | 2019-07-25 → 2019-08-08 (+14d) | 2019-07-29 → 2019-08-12 (+14d) |
| 101 | Sod and complete plantings - front yard | 2019-07-29 → 2019-08-12 (+14d) | 2019-07-31 → 2019-08-14 (+14d) |
| 102 | Sod and complete plantings - backyard | 2019-07-31 → 2019-08-14 (+14d) | 2019-08-01 → 2019-08-15 (+14d) |
| 103 | **Final Acceptance** | 2019-08-01 → 2019-08-15 (+14d) | 2019-08-13 → 2019-08-27 (+14d) |
| 104 | Complete final inspection for certificate of occupancy | 2019-08-01 → 2019-08-15 (+14d) | 2019-08-02 → 2019-08-16 (+14d) |
| 105 | Cleanup for occupancy | 2019-08-02 → 2019-08-16 (+14d) | 2019-08-05 → 2019-08-19 (+14d) |
| 106 | Perform final walk-through inspection | 2019-08-05 → 2019-08-19 (+14d) | 2019-08-06 → 2019-08-20 (+14d) |
| 107 | Complete punch list items | 2019-08-06 → 2019-08-20 (+14d) | 2019-08-13 → 2019-08-27 (+14d) |

## Version 3 (saved 2019-03-07, file Residential Construction.mpp)

Last finish 2019-08-27 → 2017-02-15 (-923d).

Changed:

| ID | Task | Start | Finish | Duration | Complete | Total float | Other |
| --- | --- | --- | --- | --- | --- | --- | --- |
| 1 | **General Conditions** | 2019-03-01 → 2016-09-05 A (-907d) | 2019-04-05 → 2016-09-26 (-921d) | 26d → 16d | 0% → 33% |  | baseline start none → 2016-09-05; baseline finish none → 2016-09-26 |
| 2 | Complete plans and develop estimate with owner, architect | 2019-03-01 → 2016-09-05 A (-907d) | 2019-04-04 → 2016-09-23 (-923d) | 5w → 3w | 0% → 33% | 0.12d → 0.25d | baseline start none → 2016-09-05; baseline finish none → 2016-09-23 |
| 3 | Sign contract and notice to proceed | 2019-04-05 → 2016-09-26 A (-921d) | 2019-04-05 → 2016-09-26 (-921d) |  | 0% → 25% |  | baseline start none → 2016-09-26; baseline finish none → 2016-09-26 |
| 4 | **Apply for Permits** | 2019-04-05 → 2016-09-26 (-921d) | 2019-04-05 → 2016-09-26 (-921d) |  |  |  | baseline start none → 2016-09-26; baseline finish none → 2016-09-26 |
| 5 | Secure foundaton permit | 2019-04-05 → 2016-09-26 (-921d) | 2019-04-05 → 2016-09-26 (-921d) |  |  |  | baseline start none → 2016-09-26; baseline finish none → 2016-09-26 |
| 6 | Secure framing permit | 2019-04-05 → 2016-09-26 (-921d) | 2019-04-05 → 2016-09-26 (-921d) |  |  |  | baseline start none → 2016-09-26; baseline finish none → 2016-09-26 |
| 7 | Secure electrical permit | 2019-04-05 → 2016-09-26 (-921d) | 2019-04-05 → 2016-09-26 (-921d) |  |  |  | baseline start none → 2016-09-26; baseline finish none → 2016-09-26 |
| 8 | Secure plumbing permit | 2019-04-05 → 2016-09-26 (-921d) | 2019-04-05 → 2016-09-26 (-921d) |  |  |  | baseline start none → 2016-09-26; baseline finish none → 2016-09-26 |
| 9 | Secure HVAC permit | 2019-04-05 → 2016-09-26 (-921d) | 2019-04-05 → 2016-09-26 (-921d) |  |  |  | baseline start none → 2016-09-26; baseline finish none → 2016-09-26 |
| 10 | Secure miscellaneous permits | 2019-04-05 → 2016-09-26 (-921d) | 2019-04-05 → 2016-09-26 (-921d) |  |  |  | baseline start none → 2016-09-26; baseline finish none → 2016-09-26 |
| 11 | **Site Work** | 2019-04-08 → 2016-09-27 (-923d) | 2019-04-10 → 2016-09-29 (-923d) |  |  |  | baseline start none → 2016-09-27; baseline finish none → 2016-09-29 |
| 12 | Clear site | 2019-04-08 → 2016-09-27 (-923d) | 2019-04-08 → 2016-09-27 (-923d) |  |  |  | baseline start none → 2016-09-27; baseline finish none → 2016-09-27 |
| 13 | Install temporary power service | 2019-04-09 → 2016-09-28 (-923d) | 2019-04-09 → 2016-09-28 (-923d) |  |  |  | baseline start none → 2016-09-28; baseline finish none → 2016-09-28 |
| 14 | Install underground utilities | 2019-04-09 → 2016-09-28 (-923d) | 2019-04-10 → 2016-09-29 (-923d) |  |  |  | baseline start none → 2016-09-28; baseline finish none → 2016-09-29 |
| 15 | **Foundation** | 2019-04-10 → 2016-09-29 (-923d) | 2019-04-29 → 2016-10-18 (-923d) |  |  |  | baseline start none → 2016-09-29; baseline finish none → 2016-10-18 |
| 16 | Excavate for foundations | 2019-04-10 → 2016-09-29 (-923d) | 2019-04-15 → 2016-10-04 (-923d) |  |  |  | baseline start none → 2016-09-29; baseline finish none → 2016-10-04 |
| 17 | Form basement walls | 2019-04-15 → 2016-10-04 (-923d) | 2019-04-19 → 2016-10-08 (-923d) |  |  |  | baseline start none → 2016-10-04; baseline finish none → 2016-10-08 |
| 18 | Pour concrete for foundations & basement walls | 2019-04-19 → 2016-10-08 (-923d) | 2019-04-23 → 2016-10-12 (-923d) |  |  |  | baseline start none → 2016-10-08; baseline finish none → 2016-10-12 |
| 19 | Strip basement wall forms | 2019-04-23 → 2016-10-12 (-923d) | 2019-04-24 → 2016-10-13 (-923d) |  |  |  | baseline start none → 2016-10-12; baseline finish none → 2016-10-13 |
| 20 | Waterproof/insulate basement walls | 2019-04-24 → 2016-10-13 (-923d) | 2019-04-25 → 2016-10-14 (-923d) |  |  |  | baseline start none → 2016-10-13; baseline finish none → 2016-10-14 |
| 21 | Perform foundation inspection | 2019-04-25 → 2016-10-14 (-923d) | 2019-04-25 → 2016-10-14 (-923d) |  |  |  | baseline start none → 2016-10-14; baseline finish none → 2016-10-14 |
| 22 | Backfill foundation | 2019-04-26 → 2016-10-17 (-921d) | 2019-04-29 → 2016-10-18 (-923d) |  |  |  | baseline start none → 2016-10-17; baseline finish none → 2016-10-18 |
| 23 | **Framing** | 2019-04-30 → 2016-10-19 (-923d) | 2019-05-29 → 2016-11-17 (-923d) |  |  |  | baseline start none → 2016-10-19; baseline finish none → 2016-11-17 |
| 24 | Install 1st floor joists | 2019-04-30 → 2016-10-19 (-923d) | 2019-05-01 → 2016-10-20 (-923d) |  |  |  | baseline start none → 2016-10-19; baseline finish none → 2016-10-20 |
| 25 | Lay 1st floor decking | 2019-05-02 → 2016-10-21 (-923d) | 2019-05-03 → 2016-10-24 (-921d) |  |  |  | baseline start none → 2016-10-21; baseline finish none → 2016-10-24 |
| 26 | Frame 1st floor walls | 2019-05-06 → 2016-10-25 (-923d) | 2019-05-09 → 2016-10-28 (-923d) |  |  |  | baseline start none → 2016-10-25; baseline finish none → 2016-10-28 |
| 27 | Frame 1st floor corners | 2019-05-10 → 2016-10-31 (-921d) | 2019-05-10 → 2016-10-31 (-921d) |  |  |  | baseline start none → 2016-10-31; baseline finish none → 2016-10-31 |
| 28 | Install 2nd floor joists | 2019-05-13 → 2016-11-01 (-923d) | 2019-05-14 → 2016-11-02 (-923d) |  |  |  | baseline start none → 2016-11-01; baseline finish none → 2016-11-02 |
| 29 | Frame 2nd floor decking | 2019-05-15 → 2016-11-03 (-923d) | 2019-05-16 → 2016-11-04 (-923d) |  |  |  | baseline start none → 2016-11-03; baseline finish none → 2016-11-04 |
| 30 | Frame 2nd floor walls | 2019-05-17 → 2016-11-07 (-921d) | 2019-05-21 → 2016-11-09 (-923d) |  |  |  | baseline start none → 2016-11-07; baseline finish none → 2016-11-09 |
| 31 | Frame 2nd floor corners | 2019-05-22 → 2016-11-10 (-923d) | 2019-05-23 → 2016-11-11 (-923d) |  |  |  | baseline start none → 2016-11-10; baseline finish none → 2016-11-11 |
| 32 | Complete roof framing | 2019-05-24 → 2016-11-14 (-921d) | 2019-05-28 → 2016-11-16 (-923d) |  |  |  | baseline start none → 2016-11-14; baseline finish none → 2016-11-16 |
| 33 | Conduct framing inspection | 2019-05-29 → 2016-11-17 (-923d) | 2019-05-29 → 2016-11-17 (-923d) |  |  |  | baseline start none → 2016-11-17; baseline finish none → 2016-11-17 |
| 34 | **Dry In** | 2019-05-29 → 2016-11-17 (-923d) | 2019-06-27 → 2016-12-16 (-923d) |  |  |  | baseline start none → 2016-11-17; baseline finish none → 2016-12-16 |
| 35 | Install 1st floor sheathing | 2019-05-29 → 2016-11-17 (-923d) | 2019-06-03 → 2016-11-22 (-923d) |  |  |  | baseline start none → 2016-11-17; baseline finish none → 2016-11-22 |
| 36 | Install 2nd floor sheathing | 2019-06-03 → 2016-11-22 (-923d) | 2019-06-06 → 2016-11-25 (-923d) |  |  |  | baseline start none → 2016-11-22; baseline finish none → 2016-11-25 |
| 37 | Install roof decking | 2019-05-29 → 2016-11-17 (-923d) | 2019-05-31 → 2016-11-21 (-921d) |  |  |  | baseline start none → 2016-11-17; baseline finish none → 2016-11-21 |
| 38 | Install felt, flashing and shingles | 2019-06-13 → 2016-12-02 (-923d) | 2019-06-18 → 2016-12-07 (-923d) |  |  |  | baseline start none → 2016-12-02; baseline finish none → 2016-12-07 |
| 39 | Hang 1st floor exterior doors | 2019-06-18 → 2016-12-07 (-923d) | 2019-06-19 → 2016-12-08 (-923d) |  |  |  | baseline start none → 2016-12-07; baseline finish none → 2016-12-08 |
| 40 | Install 1st floor windows | 2019-06-19 → 2016-12-08 (-923d) | 2019-06-24 → 2016-12-13 (-923d) |  |  |  | baseline start none → 2016-12-08; baseline finish none → 2016-12-13 |
| 41 | Install 2nd floor windows | 2019-06-24 → 2016-12-13 (-923d) | 2019-06-27 → 2016-12-16 (-923d) |  |  |  | baseline start none → 2016-12-13; baseline finish none → 2016-12-16 |
| 42 | **Exterior Finishes** | 2019-06-27 → 2016-12-16 (-923d) | 2019-07-16 → 2017-01-04 (-923d) |  |  |  | baseline start none → 2016-12-16; baseline finish none → 2017-01-04 |
| 43 | Complete exterior brick | 2019-06-27 → 2016-12-16 (-923d) | 2019-07-11 → 2016-12-30 (-923d) |  |  |  | baseline start none → 2016-12-16; baseline finish none → 2016-12-30 |
| 44 | Complete exterior siding | 2019-07-11 → 2016-12-30 (-923d) | 2019-07-16 → 2017-01-04 (-923d) |  |  |  | baseline start none → 2016-12-30; baseline finish none → 2017-01-04 |
| 45 | **Utility Rough-Ins and Complete Concrete** | 2019-06-03 → 2016-11-22 (-923d) | 2019-06-20 → 2016-12-09 (-923d) |  |  |  | baseline start none → 2016-11-22; baseline finish none → 2016-12-09 |
| 46 | Rough-in plumbing | 2019-06-06 → 2016-11-25 (-923d) | 2019-06-13 → 2016-12-02 (-923d) |  |  |  | baseline start none → 2016-11-25; baseline finish none → 2016-12-02 |
| 47 | Conduct rough-in plumbing inspection | 2019-06-13 → 2016-12-02 (-923d) | 2019-06-14 → 2016-12-05 (-921d) |  |  |  | baseline start none → 2016-12-02; baseline finish none → 2016-12-05 |
| 48 | Place concrete for basement floor | 2019-06-14 → 2016-12-05 (-921d) | 2019-06-17 → 2016-12-08 (-921d) |  |  |  | baseline start none → 2016-12-05; baseline finish none → 2016-12-08 |
| 49 | Rough-in electrical | 2019-06-06 → 2016-11-25 (-923d) | 2019-06-13 → 2016-12-02 (-923d) |  |  |  | baseline start none → 2016-11-25; baseline finish none → 2016-12-02 |
| 50 | Conduct rough-in electrical inspection | 2019-06-13 → 2016-12-02 (-923d) | 2019-06-14 → 2016-12-05 (-921d) |  |  |  | baseline start none → 2016-12-02; baseline finish none → 2016-12-05 |
| 51 | Rough-in HVAC | 2019-06-14 → 2016-12-05 (-921d) | 2019-06-19 → 2016-12-08 (-923d) |  |  |  | baseline start none → 2016-12-05; baseline finish none → 2016-12-08 |
| 52 | Conduct rough-in HVAC inspection | 2019-06-19 → 2016-12-08 (-923d) | 2019-06-20 → 2016-12-09 (-923d) |  |  |  | baseline start none → 2016-12-08; baseline finish none → 2016-12-09 |
| 53 | Rough-in communication - phone, cable, computer, alarm | 2019-06-03 → 2016-11-22 (-923d) | 2019-06-04 → 2016-11-23 (-923d) |  |  |  | baseline start none → 2016-11-22; baseline finish none → 2016-11-23 |
| 54 | **Interior Finishes** | 2019-06-27 → 2016-12-16 (-923d) | 2019-08-08 → 2017-01-27 (-923d) |  |  |  | baseline start none → 2016-12-16; baseline finish none → 2017-01-27 |
| 55 | **Insulation** | 2019-06-27 → 2016-12-16 (-923d) | 2019-07-12 → 2017-01-02 (-921d) |  |  |  | baseline start none → 2016-12-16; baseline finish none → 2017-01-02 |
| 56 | Place wall insulation - 1st floor | 2019-06-27 → 2016-12-16 (-923d) | 2019-06-28 → 2016-12-19 (-921d) |  |  |  | baseline start none → 2016-12-16; baseline finish none → 2016-12-19 |
| 57 | Place wall insulation - 2nd floor | 2019-06-28 → 2016-12-19 (-921d) | 2019-07-01 → 2016-12-20 (-923d) |  |  |  | baseline start none → 2016-12-19; baseline finish none → 2016-12-20 |
| 58 | Place ceiling insulation - 2nd floor | 2019-07-10 → 2016-12-29 (-923d) | 2019-07-11 → 2016-12-30 (-923d) |  |  |  | baseline start none → 2016-12-29; baseline finish none → 2016-12-30 |
| 59 | Conduct insulation inspection | 2019-07-11 → 2016-12-30 (-923d) | 2019-07-12 → 2017-01-02 (-921d) |  |  |  | baseline start none → 2016-12-30; baseline finish none → 2017-01-02 |
| 60 | **Drywall** | 2019-06-28 → 2016-12-19 (-921d) | 2019-07-11 → 2016-12-30 (-923d) |  |  |  | baseline start none → 2016-12-19; baseline finish none → 2016-12-30 |
| 61 | Install drywall - 1st floor walls | 2019-06-28 → 2016-12-19 (-921d) | 2019-07-02 → 2016-12-21 (-923d) |  |  |  | baseline start none → 2016-12-19; baseline finish none → 2016-12-21 |
| 62 | Install drywall - 1st floor overhead | 2019-07-02 → 2016-12-21 (-923d) | 2019-07-04 → 2016-12-23 (-923d) |  |  |  | baseline start none → 2016-12-21; baseline finish none → 2016-12-23 |
| 63 | Install drywall 2nd floor walls | 2019-07-04 → 2016-12-23 (-923d) | 2019-07-08 → 2016-12-27 (-923d) |  |  |  | baseline start none → 2016-12-23; baseline finish none → 2016-12-27 |
| 64 | Install drywall 2nd floor overhead | 2019-07-08 → 2016-12-27 (-923d) | 2019-07-10 → 2016-12-29 (-923d) |  |  |  | baseline start none → 2016-12-27; baseline finish none → 2016-12-29 |
| 65 | Tape and float 1st floor drywall | 2019-07-04 → 2016-12-23 (-923d) | 2019-07-05 → 2016-12-26 (-921d) |  |  |  | baseline start none → 2016-12-23; baseline finish none → 2016-12-26 |
| 66 | Tape and float 2nd floor drywall | 2019-07-10 → 2016-12-29 (-923d) | 2019-07-11 → 2016-12-30 (-923d) |  |  |  | baseline start none → 2016-12-29; baseline finish none → 2016-12-30 |
| 67 | **Paint and Wallpaper** | 2019-07-05 → 2016-12-26 (-921d) | 2019-07-22 → 2017-01-10 (-923d) |  |  |  | baseline start none → 2016-12-26; baseline finish none → 2017-01-10 |
| 68 | Texture all except entry and kitchen - 1st floor | 2019-07-05 → 2016-12-26 (-921d) | 2019-07-08 → 2016-12-27 (-923d) |  |  |  | baseline start none → 2016-12-26; baseline finish none → 2016-12-27 |
| 69 | Paint all except entry and kitchen - 1st floor | 2019-07-08 → 2016-12-27 (-923d) | 2019-07-09 → 2016-12-28 (-923d) |  |  |  | baseline start none → 2016-12-27; baseline finish none → 2016-12-28 |
| 70 | Hang wallpaper entry and kitchen - 1st floor | 2019-07-09 → 2016-12-28 (-923d) | 2019-07-10 → 2016-12-29 (-923d) |  |  |  | baseline start none → 2016-12-28; baseline finish none → 2016-12-29 |

| ID | Task | Start | Finish | Other |
| --- | --- | --- | --- | --- |
| 71 | Texture all - 2nd floor | 2019-07-08 → 2016-12-27 (-923d) | 2019-07-09 → 2016-12-28 (-923d) | baseline start none → 2016-12-27; baseline finish none → 2016-12-28 |
| 72 | Paint all - 2nd floor | 2019-07-09 → 2016-12-28 (-923d) | 2019-07-10 → 2016-12-29 (-923d) | baseline start none → 2016-12-28; baseline finish none → 2016-12-29 |
| 73 | Paint exterior siding & trim work | 2019-07-16 → 2017-01-04 (-923d) | 2019-07-22 → 2017-01-10 (-923d) | baseline start none → 2017-01-04; baseline finish none → 2017-01-10 |
| 74 | **Cabinets** | 2019-07-10 → 2016-12-29 (-923d) | 2019-07-18 → 2017-01-06 (-923d) | baseline start none → 2016-12-29; baseline finish none → 2017-01-06 |
| 75 | Install 1st floor - kitchen cabinets | 2019-07-10 → 2016-12-29 (-923d) | 2019-07-12 → 2017-01-02 (-921d) | baseline start none → 2016-12-29; baseline finish none → 2017-01-02 |
| 76 | Install 1st floor - master bath and guest cabinets | 2019-07-12 → 2017-01-02 (-921d) | 2019-07-15 → 2017-01-03 (-923d) | baseline start none → 2017-01-02; baseline finish none → 2017-01-03 |
| 77 | Install 2nd floor - hall bath and private bath cabinets | 2019-07-15 → 2017-01-03 (-923d) | 2019-07-16 → 2017-01-04 (-923d) | baseline start none → 2017-01-03; baseline finish none → 2017-01-04 |
| 78 | Install chair rails, crown moldings, trim | 2019-07-16 → 2017-01-04 (-923d) | 2019-07-18 → 2017-01-06 (-923d) | baseline start none → 2017-01-04; baseline finish none → 2017-01-06 |
| 79 | **Finish Plumbing** | 2019-07-12 → 2017-01-02 (-921d) | 2019-07-22 → 2017-01-10 (-923d) | baseline start none → 2017-01-02; baseline finish none → 2017-01-10 |
| 80 | Complete 1st floor - kitchen plumbing | 2019-07-12 → 2017-01-02 (-921d) | 2019-07-15 → 2017-01-03 (-923d) | baseline start none → 2017-01-02; baseline finish none → 2017-01-03 |
| 81 | Complete 1st floor - master bath and guest plumbing | 2019-07-15 → 2017-01-03 (-923d) | 2019-07-17 → 2017-01-05 (-923d) | baseline start none → 2017-01-03; baseline finish none → 2017-01-05 |
| 82 | Complete 2nd floor - hall bath and private bath plumbing | 2019-07-17 → 2017-01-05 (-923d) | 2019-07-19 → 2017-01-09 (-921d) | baseline start none → 2017-01-05; baseline finish none → 2017-01-09 |
| 83 | Conduct finish plumbing inspection | 2019-07-19 → 2017-01-09 (-921d) | 2019-07-22 → 2017-01-10 (-923d) | baseline start none → 2017-01-09; baseline finish none → 2017-01-10 |
| 84 | **Finish Electrical** | 2019-07-19 → 2017-01-09 (-921d) | 2019-07-24 → 2017-01-12 (-923d) | baseline start none → 2017-01-09; baseline finish none → 2017-01-12 |
| 85 | Complete 1st floor circuits to service panel | 2019-07-19 → 2017-01-09 (-921d) | 2019-07-22 → 2017-01-10 (-923d) | baseline start none → 2017-01-09; baseline finish none → 2017-01-10 |
| 86 | Complete 2nd floor circuits to service panel | 2019-07-22 → 2017-01-10 (-923d) | 2019-07-23 → 2017-01-11 (-923d) | baseline start none → 2017-01-10; baseline finish none → 2017-01-11 |
| 87 | Conduct finish electrical inspection | 2019-07-23 → 2017-01-11 (-923d) | 2019-07-24 → 2017-01-12 (-923d) | baseline start none → 2017-01-11; baseline finish none → 2017-01-12 |
| 88 | Complete communications wiring - phone, cable, computer, alarm | 2019-07-22 → 2017-01-10 (-923d) | 2019-07-24 → 2017-01-12 (-923d) | baseline start none → 2017-01-10; baseline finish none → 2017-01-12 |
| 89 | **Finish HVAC** | 2019-07-24 → 2017-01-12 (-923d) | 2019-07-29 → 2017-01-17 (-923d) | baseline start none → 2017-01-12; baseline finish none → 2017-01-17 |
| 90 | Complete 1st floor - zone 1 HVAC | 2019-07-24 → 2017-01-12 (-923d) | 2019-07-25 → 2017-01-13 (-923d) | baseline start none → 2017-01-12; baseline finish none → 2017-01-13 |
| 91 | Complete 2nd floor - zone 2 HVAC | 2019-07-25 → 2017-01-13 (-923d) | 2019-07-26 → 2017-01-16 (-921d) | baseline start none → 2017-01-13; baseline finish none → 2017-01-16 |
| 92 | Conduct HVAC inspection | 2019-07-26 → 2017-01-16 (-921d) | 2019-07-29 → 2017-01-17 (-923d) | baseline start none → 2017-01-16; baseline finish none → 2017-01-17 |
| 93 | **Carpet, Tile and Appliances** | 2019-07-29 → 2017-01-17 (-923d) | 2019-08-08 → 2017-01-27 (-923d) | baseline start none → 2017-01-17; baseline finish none → 2017-01-27 |
| 94 | Tile entry, kitchen and baths | 2019-07-29 → 2017-01-17 (-923d) | 2019-08-01 → 2017-01-20 (-923d) | baseline start none → 2017-01-17; baseline finish none → 2017-01-20 |
| 95 | Carpet 1st floor | 2019-08-01 → 2017-01-20 (-923d) | 2019-08-05 → 2017-01-24 (-923d) | baseline start none → 2017-01-20; baseline finish none → 2017-01-24 |
| 96 | Carpet 2nd floor | 2019-08-05 → 2017-01-24 (-923d) | 2019-08-07 → 2017-01-26 (-923d) | baseline start none → 2017-01-24; baseline finish none → 2017-01-26 |
| 97 | Install appliances | 2019-08-07 → 2017-01-26 (-923d) | 2019-08-08 → 2017-01-27 (-923d) | baseline start none → 2017-01-26; baseline finish none → 2017-01-27 |
| 98 | **Landscaping and Grounds Work** | 2019-07-22 → 2017-01-10 (-923d) | 2019-08-15 → 2017-02-03 (-923d) | baseline start none → 2017-01-10; baseline finish none → 2017-02-03 |
| 99 | Pour concrete driveway and sidewalks | 2019-07-22 → 2017-01-10 (-923d) | 2019-07-23 → 2017-01-11 (-923d) | baseline start none → 2017-01-10; baseline finish none → 2017-01-11 |
| 100 | Install backyard fence | 2019-08-08 → 2017-01-27 (-923d) | 2019-08-12 → 2017-01-31 (-923d) | baseline start none → 2017-01-27; baseline finish none → 2017-01-31 |
| 101 | Sod and complete plantings - front yard | 2019-08-12 → 2017-01-31 (-923d) | 2019-08-14 → 2017-02-02 (-923d) | baseline start none → 2017-01-31; baseline finish none → 2017-02-02 |
| 102 | Sod and complete plantings - backyard | 2019-08-14 → 2017-02-02 (-923d) | 2019-08-15 → 2017-02-03 (-923d) | baseline start none → 2017-02-02; baseline finish none → 2017-02-03 |
| 103 | **Final Acceptance** | 2019-08-15 → 2017-02-03 (-923d) | 2019-08-27 → 2017-02-15 (-923d) | baseline start none → 2017-02-03; baseline finish none → 2017-02-14 |
| 104 | Complete final inspection for certificate of occupancy | 2019-08-15 → 2017-02-03 (-923d) | 2019-08-16 → 2017-02-06 (-921d) | baseline start none → 2017-02-03; baseline finish none → 2017-02-06 |
| 105 | Cleanup for occupancy | 2019-08-16 → 2017-02-06 (-921d) | 2019-08-19 → 2017-02-07 (-923d) | baseline start none → 2017-02-06; baseline finish none → 2017-02-07 |
| 106 | Perform final walk-through inspection | 2019-08-19 → 2017-02-07 (-923d) | 2019-08-20 → 2017-02-08 (-923d) | baseline start none → 2017-02-07; baseline finish none → 2017-02-08 |
| 107 | Complete punch list items | 2019-08-20 → 2017-02-08 (-923d) | 2019-08-27 → 2017-02-15 (-923d) | baseline start none → 2017-02-08; baseline finish none → 2017-02-14 |
